# CRM-session-01-debut

Schedule from MS Project, 2019-03-04 to 2019-05-22, 7 hours a day.
Microsoft

## Calendars

- Standard: Mon-Fri 08:00-12:00, 13:00-17:00; Sat-Sun off.

## Resources

| Resource |
| --- |
| Stackholder1 |
| Stackholder2 |
| PM1 |
| Integrator1 |
| integrator2 |
| user1 |
| user2 |
| user3 |
| user4 |
| user5 |
| accountant1 |
| accountant2 |
| Consultant1 |
| Consultant2 |
| user6 |
| CMO |
| Marketing Assistant |

## Schedule

| ID | WBS | Task | Type | Duration | Start | Finish | Predecessors | Total slack | Free slack | Constraint |
| --- | --- | --- | --- | --- | --- | --- | --- | --- | --- | --- |
| 1 | 1 | **CRM** |  | 66d | 2019-03-04 | 2019-05-22 |  | 0d |  |  |
| 2 | 1.1 | **Initiation** |  | 1d | 2019-03-04 | 2019-03-04 |  | 65d |  |  |
| 3 | 1.1.1 | Project proposal |  | 1d | 2019-03-04 | 2019-03-04 |  | 65d |  |  |
| 4 | 1.1.2 | Project approval | milestone | 0d | 2019-03-04 | 2019-03-04 |  | 66d |  |  |
| 5 | 1.2 | **Planning** |  | 0.5d | 2019-03-04 | 2019-03-04 |  | 65.5d |  |  |
| 6 | 1.2.1 | Planning session |  | 0.5d | 2019-03-04 | 2019-03-04 |  | 65.5d |  |  |
| 7 | 1.3 | **Execution / Realisation** |  | 55.71d | 2019-03-04 | 2019-05-09 |  | 10.29d |  |  |
| 8 | 1.3.1 | **Conception** |  | 16.5d | 2019-03-04 | 2019-03-22 |  | 29.5d |  |  |
| 9 | 1.3.1.1 | Requirements |  | 1d | 2019-03-04 | 2019-03-04 |  | 29.5d | 0d |  |
| 10 | 1.3.1.2 | Solutions evaluation |  | 2w | 2019-03-05 | 2019-03-15 | 9 | 29.5d | 0d |  |
| 11 | 1.3.1.3 | Solution choice |  | 0.5d | 2019-03-15 | 2019-03-18 | 10 | 29.5d | 0d |  |
| 12 | 1.3.1.4 | System purchase |  | 1w | 2019-03-18 | 2019-03-22 | 11 | 29.5d | 0d |  |
| 13 | 1.3.2 | **System integration** |  | 10d | 2019-03-22 | 2019-04-04 |  | 29.5d |  |  |
| 14 | 1.3.2.1 | Server installation |  | 2d | 2019-03-22 | 2019-03-26 | 12 | 29.5d | 0d |  |
| 15 | 1.3.2.2 | Application installation |  | 8d | 2019-03-26 | 2019-04-04 | 14 | 29.5d | 0d |  |
| 16 | 1.3.3 | **Test / Training** |  | 10d | 2019-04-04 | 2019-04-17 |  | 29.5d |  |  |
| 17 | 1.3.3.1 | Test UI |  | 4d | 2019-04-04 | 2019-04-09 | 15 | 29.5d | 0d |  |
| 18 | 1.3.3.2 | Functionnal test |  | 6d | 2019-04-09 | 2019-04-17 | 17 | 29.5d |  |  |
| 19 | 1.3.3.3 | Training |  | 4d | 2019-04-04 | 2019-04-09 | 15 | 35.5d |  |  |
| 20 | 1.3.4 | **Production** |  | 10d | 2019-04-29 | 2019-05-09 |  | 0d |  |  |
| 21 | 1.3.4.1 | In production | milestone | 0d | 2019-04-29 | 2019-04-29 |  | 0d |  | start no earlier than 2019-04-29 |
| 22 | 1.3.4.2 | Production run |  | 2w | 2019-04-29 | 2019-05-09 | 21 | 0d |  |  |
| 23 | 1.4 | **Project Closing** |  | 0.29d | 2019-05-22 | 2019-05-22 | 22FS+2w | 0d |  |  |
| 24 | 1.4.1 | Closing meeting |  | 2h | 2019-05-22 | 2019-05-22 |  | 0d |  |  |
